# Software Development

Schedule from MS Project, 2012-03-19 to 2014-01-09, costs in $, A marks actual dates.

## Calendars

- Standard: Mon-Fri 08:00-12:00, 13:00-17:00; Sat-Sun off.

## Resources

| Resource | Rate |
| --- | --- |
| Project Sponsor | 102 |
| Project Manager | 51.5 |
| Analyst | 35.15 |
| Developer | 39.77 |
| Testers | 22 |
| Trainers | 24.57 |
| IT Manager | 41.8 |
| IT Admin | 15 |
| HR Manager | 31.77 |
| Project Team | 150 |

## Schedule

| ID | WBS | Task | Type | Duration | Start | Finish | Predecessors | Complete | Remaining | Total slack | Free slack | Resources | Work | Actual work | Cost | Actual cost |
| --- | --- | --- | --- | --- | --- | --- | --- | --- | --- | --- | --- | --- | --- | --- | --- | --- |
| 1 | 1 | **Scope** |  | 3.5d | 2012-03-19 A | 2012-03-22 |  | 99% | 0d |  |  |  | 28h | 28h | 1,846 | 1,846 |
| 2 | 1.1 | Determine project scope | manual | 4h | 2012-03-19 A | 2012-03-19 A |  | 100% |  |  |  | Project Manager | 4h | 4h | 206 | 206 |
| 3 | 1.2 | Secure project sponsorship |  | 1d | 2012-03-19 A | 2012-03-20 | 2 | 99% | 0d | 1d | 0d | Project Sponsor; Project Manager | 8h | 8h | 816 | 816 |
| 4 | 1.3 | Define preliminary resources |  | 1d | 2012-03-20 A | 2012-03-21 | 3 | 99% | 0d | 1d | 0d | Project Manager; Project Sponsor | 8h | 8h | 412 | 412 |
| 5 | 1.4 | Secure core resources |  | 1d | 2012-03-21 A | 2012-03-22 | 4 | 99% | 0d | 470.5d |  | Project Manager; Project Sponsor | 8h | 8h | 412 | 412 |
| 6 | 1.5 | Scope Complete | milestone, manual | 0d | 2012-03-22 | 2012-03-22 |  |  |  |  |  |  |  |  |  |  |
| 7 | 2 | **Analysis/Software Requirements** |  | 14d | 2012-03-22 A | 2012-04-11 |  | 99% | 0d | 456.5d |  |  | 120h | 120h | 6,185.8 | 6,185.8 |
| 8 | 2.1 | Conduct needs analysis |  | 5d | 2012-03-22 A | 2012-03-29 | 6 | 99% | 0d | 3d | 0d | Project Manager; HR Manager | 40h | 40h | 2,060 | 2,060 |
| 9 | 2.2 | Draft preliminary software specifications |  | 3d | 2012-03-29 A | 2012-04-03 | 8 | 99% | 0d | 462.5d |  | Project Manager; HR Manager; IT Admin | 24h | 24h | 1,236 | 1,236 |
| 10 | 2.3 | Develop preliminary budget |  | 2d | 2012-04-03 A | 2012-04-05 A | 9 | 100% |  |  |  | Project Manager | 16h | 16h | 824 | 824 |
| 11 | 2.4 | Review software specifications/budget with team |  | 4h | 2012-04-05 A | 2012-04-05 A | 10 | 100% |  |  |  | Project Manager; Analyst | 8h | 8h | 346.6 | 346.6 |
| 12 | 2.5 | Incorporate feedback on software specifications |  | 1d | 2012-04-06 A | 2012-04-06 A | 11 | 100% |  |  |  | Analyst | 8h | 8h | 281.2 | 281.2 |
| 13 | 2.6 | Develop delivery timeline |  | 1d | 2012-04-09 A | 2012-04-09 A | 12 | 100% |  |  |  | Project Manager | 8h | 8h | 412 | 412 |
| 14 | 2.7 | Obtain approvals to proceed (concept, timeline, budget) |  | 4h | 2012-04-10 A | 2012-04-10 A | 13 | 100% |  |  |  | Project Sponsor; Project Manager | 8h | 8h | 614 | 614 |
| 15 | 2.8 | Secure required resources |  | 1d | 2012-04-10 A | 2012-04-11 A | 14 | 100% |  |  |  | Project Manager | 8h | 8h | 412 | 412 |
| 16 | 2.9 | Analysis Complete | milestone, manual | 0d | 2012-04-11 | 2012-04-11 | 15 |  |  |  |  |  |  |  |  |  |
| 17 | 3 | **Design** |  | 454.5d | 2012-04-13 A | 2014-01-09 |  | 86% | 62.69d | 0d |  |  | 120h | 104h | 5,066.56 | 4,558.24 |
| 18 | 3.1 | Review preliminary software specifications |  | 2d | 2014-01-06 | 2014-01-09 |  |  |  | 0d |  | HR Manager | 16h |  | 508.32 |  |
| 19 | 3.2 | Develop functional specifications |  | 5d | 2012-04-13 A | 2012-04-20 A | 18 | 100% |  |  |  | Developer | 40h | 40h | 1,590.8 | 1,590.8 |
| 20 | 3.3 | Develop prototype based on functional specifications |  | 4d | 2012-04-20 A | 2012-04-26 A | 19 | 100% |  |  |  | Developer | 32h | 32h | 1,272.64 | 1,272.64 |
| 21 | 3.4 | Review functional specifications |  | 2d | 2012-04-26 A | 2012-04-30 | 20 | 99% | 0d | 443.5d |  | HR Manager; IT Manager; Project Manager | 16h | 16h | 668.8 | 668.8 |
| 22 | 3.5 | Incorporate feedback into functional specifications |  | 1d | 2012-04-30 A | 2012-05-01 A | 21 | 100% |  |  |  | Project Manager | 8h | 8h | 412 | 412 |
| 23 | 3.6 | Obtain approval to proceed |  | 4h | 2012-05-01 A | 2012-05-01 A | 22 | 100% |  |  |  | Project Sponsor; Project Manager | 8h | 8h | 614 | 614 |
| 24 | 3.7 | Design Complete | milestone, manual | 0d | 2012-05-02 | 2012-05-02 | 23 |  |  |  |  | Project Manager; Project Team |  |  |  |  |

| ID | WBS | Task | Type | Duration | Start | Finish | Predecessors | Complete | Remaining | Total slack | Resources | Work | Actual work | Cost | Actual cost |
| --- | --- | --- | --- | --- | --- | --- | --- | --- | --- | --- | --- | --- | --- | --- | --- |
| 25 | 4 | **Development** |  | 20.75d | 2012-05-03 A | 2012-05-31 |  | 99% | 0d | 420.25d |  | 256h | 256h | 10,181.12 | 10,181.12 |
| 26 | 4.1 | Identify modular/tiered design parameters |  | 1d | 2012-05-03 A | 2012-05-03 |  | 99% | 0d | 61.75d | Developer; Analyst | 8h | 8h | 318.16 | 318.16 |
| 27 | 4.2 | Assign development staff |  | 1d | 2012-05-04 A | 2012-05-04 A | 26 | 100% |  |  | Developer | 8h | 8h | 318.16 | 318.16 |
| 28 | 4.3 | Develop code |  | 15d | 2012-05-07 A | 2012-05-25 A | 27 | 100% |  |  | Developer | 120h | 120h | 4,772.4 | 4,772.4 |
| 29 | 4.4 | Developer testing (primary debugging) |  | 15d | 2012-05-10 A | 2012-05-31 A | 28FS-7.5% | 100% |  |  | Developer | 120h | 120h | 4,772.4 | 4,772.4 |
| 30 | 4.5 | Development Complete | milestone, manual | 0d | 2012-05-31 | 2012-05-31 | 29 |  |  |  |  |  |  |  |  |
| 31 | 5 | **Testing** |  | 48.75d | 2012-05-02 A | 2012-07-09 |  | 99% | 0d | 393.25d |  | 280h | 280h | 19,472 | 19,472 |
| 32 | 5.1 | Develop unit test plans using product specifications |  | 4d | 2012-05-02 A | 2012-05-07 |  | 99% | 0d | 59.75d | Testers; Developer | 32h | 32h | 704 | 704 |
| 33 | 5.2 | Develop integration test plans using product specifications |  | 4d | 2012-05-08 A | 2012-05-11 |  | 99% | 0d | 55.75d | Testers; Developer | 32h | 32h | 704 | 704 |
| 34 | 5.3 | **Unit Testing** |  | 15d | 2012-05-31 A | 2012-06-21 |  | 99% | 0d | 0d |  | 120h | 120h | 15,952 | 15,952 |
| 35 | 5.3.1 | Review modular code |  | 5d | 2012-05-31 A | 2012-06-07 A | 32 | 100% |  |  | Project Team | 40h | 40h | 6,000 | 6,000 |
| 36 | 5.3.2 | Test component modules to product specifications |  | 2d | 2012-06-07 A | 2012-06-11 A | 35 | 100% |  |  | Testers | 16h | 16h | 352 | 352 |
| 37 | 5.3.3 | Identify anomalies to product specifications |  | 3d | 2012-06-11 A | 2012-06-14 A | 36 | 100% |  |  | Project Team | 24h | 24h | 3,600 | 3,600 |
| 38 | 5.3.4 | Modify code |  | 3d | 2012-06-14 A | 2012-06-19 A | 37 | 100% |  |  | Project Team | 24h | 24h | 3,600 | 3,600 |
| 39 | 5.3.5 | Re-test modified code |  | 2d | 2012-06-19 A | 2012-06-21 A | 38 | 100% |  |  | Project Team | 16h | 16h | 2,400 | 2,400 |
| 40 | 5.3.6 | Unit Testing Complete | milestone, manual | 0d | 2012-06-21 | 2012-06-21 | 39 |  |  |  |  |  |  |  |  |
| 41 | 5.4 | **Integration Testing** |  | 12d | 2012-06-21 A | 2012-07-09 |  | 99% | 0d | 0d |  | 96h | 96h | 2,112 | 2,112 |
| 42 | 5.4.1 | Test module integration |  | 5d | 2012-06-21 A | 2012-06-28 A | 40 | 100% |  |  | Testers | 40h | 40h | 880 | 880 |
| 43 | 5.4.2 | Identify anomalies to specifications |  | 2d | 2012-06-28 A | 2012-07-02 A | 42 | 100% |  |  | Testers | 16h | 16h | 352 | 352 |
| 44 | 5.4.3 | Modify code |  | 3d | 2012-07-02 A | 2012-07-05 A | 43 | 100% |  |  | Testers | 24h | 24h | 528 | 528 |
| 45 | 5.4.4 | Re-test modified code |  | 2d | 2012-07-05 A | 2012-07-09 A | 44 | 100% |  |  | Testers | 16h | 16h | 352 | 352 |
| 46 | 5.4.5 | Integration Testing Complete | milestone, manual | 0d | 2012-07-09 | 2012-07-09 | 45 |  |  |  |  |  |  |  |  |
| 47 | 6 | **Training** |  | 45.75d | 2012-05-02 A | 2012-07-04 |  | 99% | 0d | 396.25d |  | 256h | 256h | 6,289.92 | 6,289.92 |
| 48 | 6.1 | Develop training specifications for end users |  | 3d | 2012-05-07 A | 2012-05-09 |  | 99% | 0d | 57.75d | Trainers; HR Manager | 24h | 24h | 589.68 | 589.68 |
| 49 | 6.2 | Develop training specifications for helpdesk support staff |  | 3d | 2012-05-04 A | 2012-05-11 A |  | 100% |  |  | Trainers | 24h | 24h | 589.68 | 589.68 |
| 50 | 6.3 | Identify training delivery methodology (computer based training, classroom, etc.) |  | 2d | 2012-05-02 A | 2012-05-03 A |  | 100% |  |  | Trainers | 16h | 16h | 393.12 | 393.12 |
| 51 | 6.4 | Develop training materials |  | 3w | 2012-05-31 A | 2012-06-21 A | 48, 49, 50 | 100% |  |  | Trainers | 120h | 120h | 2,948.4 | 2,948.4 |
| 52 | 6.5 | Conduct training usability study |  | 4d | 2012-06-21 A | 2012-06-27 A | 51 | 100% |  |  | Trainers | 32h | 32h | 786.24 | 786.24 |
| 53 | 6.6 | Finalize training materials |  | 3d | 2012-06-27 A | 2012-07-02 A | 52 | 100% |  |  | Trainers | 24h | 24h | 589.68 | 589.68 |
| 54 | 6.7 | Develop training delivery mechanism |  | 2d | 2012-07-02 A | 2012-07-04 A | 53 | 100% |  |  | Trainers | 16h | 16h | 393.12 | 393.12 |
| 55 | 6.8 | Training Materials Complete | milestone, manual | 0d | 2012-07-04 | 2012-07-04 | 54 |  |  |  |  |  |  |  |  |

| ID | WBS | Task | Type | Duration | Start | Finish | Predecessors | Complete | Remaining | Total slack | Free slack | Resources | Work | Actual work | Cost | Actual cost |
| --- | --- | --- | --- | --- | --- | --- | --- | --- | --- | --- | --- | --- | --- | --- | --- | --- |
| 56 | 7 | **Documentation** |  | 59.5d | 2012-03-22 A | 2012-06-13 |  | 97% | 2.05d | 411.5d |  |  | 376h | 368h | 10,422.48 | 10,088.08 |
| 57 | 7.1 | Develop Help specification |  | 1d | 2012-03-22 A | 2012-03-22 |  | 99% | 0d | 91.75d |  | IT Manager; IT Admin | 8h | 8h | 334.4 | 334.4 |
| 58 | 7.2 | Develop Help system |  | 3d | 2012-05-16 A | 2012-06-11 A | 57, 28FS-5% | 100% |  |  |  | Developer | 24h | 24h | 954.48 | 954.48 |
| 59 | 7.3 | Review Help documentation |  | 3d | 2012-06-06 A | 2012-06-12 | 58 | 67% | 1d | 1d | 0d | IT Manager | 24h | 16h | 1,003.2 | 668.8 |
| 60 | 7.4 | Incorporate Help documentation feedback |  | 2d | 2012-06-11 A | 2012-06-13 | 59 | 99% | 0d | 411.5d |  | IT Admin; Project Team | 16h | 16h | 240 | 240 |
| 61 | 7.5 | Develop user manuals specifications |  | 3d | 2012-05-02 A | 2012-05-04 A |  | 100% |  |  |  | Analyst; IT Admin | 48h | 48h | 1,203.6 | 1,203.6 |
| 62 | 7.6 | Develop user manuals |  | 3w | 2012-05-16 A | 2012-06-06 A | 61, 28FS-5% | 100% |  |  |  | Analyst; IT Admin | 240h | 240h | 6,018 | 6,018 |
| 63 | 7.7 | Review all user documentation |  | 2d | 2012-06-06 A | 2012-06-08 A | 62 | 100% |  |  |  | IT Manager | 16h | 16h | 668.8 | 668.8 |
| 64 | 7.8 | Documentation Complete | milestone, manual | 0d | 2012-06-12 | 2012-06-12 | 63 |  |  |  |  |  |  |  |  |  |
| 65 | 8 | **Integration - Legacy Systems** |  | 70.25d | 2012-04-11 A | 2012-07-18 |  | 99% | 0d | 0d |  |  | 72h | 72h | 9,068.8 | 9,068.8 |
| 66 | 8.1 | Identify Legacy Software |  | 1d | 2012-04-11 A | 2012-04-12 A |  | 100% |  |  |  | IT Manager | 8h | 8h | 334.4 | 334.4 |
| 67 | 8.2 | Begin Integration Process |  | 1d | 2012-04-12 A | 2012-04-13 A | 66 | 100% |  |  |  | IT Manager | 8h | 8h | 334.4 | 334.4 |
| 68 | 8.3 | Transfer to new software |  | 1d | 2012-07-09 A | 2012-07-10 A | 67 | 100% |  |  |  | Project Team | 8h | 8h | 1,200 | 1,200 |
| 69 | 8.4 | Test in batches |  | 1w | 2012-07-10 A | 2012-07-17 A | 68 | 100% |  |  |  | Project Team | 40h | 40h | 6,000 | 6,000 |
| 70 | 8.5 | Evaluate testing information |  | 1d | 2012-07-17 A | 2012-07-18 A | 69 | 100% |  |  |  | Project Team | 8h | 8h | 1,200 | 1,200 |
| 71 | 8.6 | Pilot Complete | milestone, manual | 0d | 2012-07-18 | 2012-07-18 | 70 |  |  |  |  |  |  |  |  |  |
| 72 | 9 | **Deployment** |  | 5d | 2012-07-18 A | 2012-07-25 |  | 99% | 0d | 0d |  |  | 40h | 40h | 6,000 | 6,000 |
| 73 | 9.1 | Determine final deployment strategy |  | 1d | 2012-07-18 A | 2012-07-19 A | 71 | 100% |  |  |  | Project Team | 8h | 8h | 1,200 | 1,200 |
| 74 | 9.2 | Develop deployment methodology |  | 1d | 2012-07-19 A | 2012-07-20 A | 73 | 100% |  |  |  | Project Team | 8h | 8h | 1,200 | 1,200 |
| 75 | 9.3 | Secure deployment resources |  | 1d | 2012-07-20 A | 2012-07-23 A | 74 | 100% |  |  |  | Project Team | 8h | 8h | 1,200 | 1,200 |
| 76 | 9.4 | Train support staff |  | 1d | 2012-07-23 A | 2012-07-24 A | 75 | 100% |  |  |  | Project Team | 8h | 8h | 1,200 | 1,200 |
| 77 | 9.5 | Deploy new integrated software system |  | 1d | 2012-07-24 A | 2012-07-25 A | 76 | 100% |  |  |  | Project Team | 8h | 8h | 1,200 | 1,200 |
| 78 | 9.6 | Deployment Complete | milestone, manual | 0d | 2012-07-25 | 2012-07-25 | 77 |  |  |  |  |  |  |  |  |  |
| 79 | 10 | **Post Implementation Review** |  | 3d? | 2012-07-25 A | 2012-07-30 |  | 75% | 0.75d? | 378.25d |  |  | 24h | 24h | 1,236 | 1,236 |
| 80 | 10.1 | Document lessons learned |  | 1d | 2012-07-25 A | 2012-07-26 | 78 | 99% | 0d | 380.25d |  | Project Manager; Project Team | 8h | 8h | 412 | 412 |
| 81 | 10.2 | Distribute to team members |  | 1d | 2012-07-26 A | 2012-07-27 A | 80 | 100% |  |  |  | Project Manager | 8h | 8h | 412 | 412 |
| 82 | 10.3 | Create software maintenance team |  | 1d | 2012-07-27 A | 2012-07-30 A | 81 | 100% |  |  |  | Project Manager | 8h | 8h | 412 | 412 |
| 83 | 10.4 | Post Implementation Review Complete | milestone, manual | 0d | 2012-07-30 | 2012-07-30 | 82 |  |  |  |  |  |  |  |  |  |
| 84 | 10.5 | Close Project | manual | 1d? | 2012-07-25 | 2012-07-26 |  |  |  |  |  |  |  |  |  |  |
